# OntoMapper Schedule

Schedule from MS Project, 2009-03-25 to 2009-08-19, A marks actual dates.
Academic Research Systems, UCSF

## Calendars

- Standard: Mon-Fri 08:00-12:00, 13:00-17:00; Sat-Sun off.

## Resources

| Resource |
| --- |
| John D. |
| John G. |
| Group |
| RecomData |
| John D. John G. |
| Rob W. |
| Davera |
| Hillari |
| Rakesh D |
| Shannon |
| Chandra |
| Ketty |
| Nick |
| Kent |
| Rakesh D. |
| Maggie |
| Marco |
| David E. |
| NCI |
| Ida Sim Team |
| Andy Auerbach Team |
| Jen Puck Team |
| Jen Puck |
| Lorraine Frasier Team |
| Nick Anderson Team |
| David Eichman |
| David Eichman Team |
| Joel White Tieam |
| Paul |
| Prakash |
| Rob |

## Schedule

| ID | WBS | Task | Type | Duration | Start | Finish | Predecessors | Complete | Remaining | Total slack | Free slack | Resources | Work | Actual work |
| --- | --- | --- | --- | --- | --- | --- | --- | --- | --- | --- | --- | --- | --- | --- |
| 1 | 1 | **Regression Testing** |  | 23.7d? | 2009-03-25 A | 2009-04-27 |  | 29% | 16.87d? | 82.3d |  |  | 664h | 243.2h |
| 2 | 1.1 | Alpha System Implementation - Completed |  | 1d? | 2009-03-25 A | 2009-03-25 A |  | 100% |  |  |  | Prakash; Chandra; Rob W. | 24h | 24h |
| 3 | 1.2 | Beefy Dinky Data Set |  | 10d | 2009-03-25 A | 2009-04-07 A | 2 | 100% |  |  |  | Ketty; Hillari | 160h | 160h |
| 4 | 1.3 | ETL of Beefy Dinky |  | 1d? | 2009-04-08 A | 2009-04-08 A | 3 | 100% |  |  |  | Ketty; Paul | 16h | 16h |
| 5 | 1.4 | Avenda Use Case Maps |  | 3d | 2009-04-08 A | 2009-04-13 | 4 | 10% | 2.7d | 82.3d | 0d | Chandra; Ketty | 48h | 4.8h |
| 6 | 1.5 | Regression Scripts |  | 10d | 2009-04-13 | 2009-04-27 | 5 |  |  | 82.3d |  | Hillari | 80h |  |
| 7 | 1.6 | **Alpha Test Phase** |  | 16d? | 2009-03-25 A | 2009-04-15 |  | 9% | 14.52d? | 90d |  |  | 336h | 38.4h |
| 8 | 1.6.1 | Apha Site Installs |  | 10d | 2009-03-25 | 2009-04-07 |  |  |  | 0d |  | Chandra | 80h |  |
| 9 | 1.6.2 | **Group 1** |  | 3d? | 2009-04-08 A | 2009-04-10 | 8 | 24% | 2.28d? | 0d |  |  | 160h | 38.4h |
| 10 | 1.6.2.1 | UCSF |  | 3d | 2009-04-08 A | 2009-04-10 |  | 80% | 0.6d | 0d |  | Hillari; Ketty | 48h | 38.4h |
| 11 | 1.6.2.2 | UW |  | 3d | 2009-04-08 | 2009-04-10 |  |  |  | 0d |  | Hillari; Nick | 48h |  |
| 12 | 1.6.2.3 | UCD |  | 3d | 2009-04-08 | 2009-04-10 |  |  |  | 0d |  | Hillari; Kent | 48h |  |
| 13 | 1.6.2.4 | OSU |  | 1d? | 2009-04-08 | 2009-04-08 |  |  |  | 2d |  | Hillari; Rakesh D. | 16h |  |
| 14 | 1.6.3 | **Group 2** |  | 3d | 2009-04-13 | 2009-04-15 | 9 |  |  | 0d |  |  | 96h |  |
| 15 | 1.6.3.1 | Upenn |  | 3d | 2009-04-13 | 2009-04-15 |  |  |  | 90d |  | Hillari; Maggie | 48h |  |
| 16 | 1.6.3.2 | Rochester |  | 3d | 2009-04-13 | 2009-04-15 |  |  |  | 0d |  | Hillari; Marco | 48h |  |
| 17 | 1.6.3.3 | All Testing Completed | milestone | 0d | 2009-04-15 | 2009-04-15 | 16 |  |  | 0d |  |  |  |  |
| 18 | 2 | **i2b2 Cell Wrapper** |  | 20d | 2009-03-25 | 2009-04-21 |  |  |  | 86d |  |  | 160h |  |
| 19 | 2.1 | Soap Interface Defs |  | 5d | 2009-03-25 | 2009-03-31 |  |  |  | 86d | 0d | RecomData | 40h |  |
| 20 | 2.2 | Data Delivery Pipleline |  | 5d | 2009-04-01 | 2009-04-07 | 19 |  |  | 86d | 0d | RecomData | 40h |  |
| 21 | 2.3 | SHRINE Integration - do we move past the Obs Fact View mech? |  | 5d | 2009-04-08 | 2009-04-14 | 20 |  |  | 86d | 0d | RecomData | 40h |  |
| 22 | 2.4 | Installation Scripts (Database and Servlet) |  | 5d | 2009-04-15 | 2009-04-21 | 21 |  |  | 86d |  | RecomData | 40h |  |
| 23 | 3 | **CTSpedia.org Site Setup** |  | 4d? | 2009-03-25 A | 2009-03-30 |  | 88% | 0.5d? | 102d |  |  | 32h | 28h |
| 24 | 3.1 | Template Definition |  | 3d | 2009-03-25 A | 2009-03-27 A |  | 100% |  |  |  | Ketty | 24h | 24h |
| 25 | 3.2 | Site Setup |  | 1d? | 2009-03-30 A | 2009-03-30 | 24 | 50% | 0.5d? | 102d |  | Hillari | 8h | 4h |

| ID | WBS | Task | Type | Duration | Start | Finish | Predecessors | Complete | Remaining | Total slack | Free slack | Resources | Work | Actual work |
| --- | --- | --- | --- | --- | --- | --- | --- | --- | --- | --- | --- | --- | --- | --- |
| 26 | 4 | **Alpha System Updates** |  | 12.3d? | 2009-03-25 A | 2009-04-10 |  | 32% | 8.42d? | 93.7d |  |  | 152h | 48h |
| 27 | 4.1 | GUI Updates - Style Sheets and AJAX |  | 1d? | 2009-03-30 | 2009-03-31 | 30 |  |  | 93.7d | 0d | Chandra | 8h |  |
| 28 | 4.2 | **Scripting Languages** |  | 12.3d | 2009-03-25 A | 2009-04-10 |  | 33% | 8.2d | 93.7d |  |  | 144h | 48h |
| 29 | 4.2.1 | SQL |  | 3d | 2009-03-25 A | 2009-03-27 A |  | 100% |  |  |  | Chandra | 24h | 24h |
| 30 | 4.2.2 | Perl |  | 3d | 2009-03-25 A | 2009-03-30 A | 29 | 100% |  |  |  | Chandra | 24h | 24h |
| 31 | 4.2.3 | SparQL |  | 4d | 2009-03-30 | 2009-04-03 | 30 |  |  | 98.7d |  | Chandra | 32h |  |
| 32 | 4.2.4 | R |  | 4d | 2009-03-31 | 2009-04-06 | 27 |  |  | 93.7d | 0d | Chandra | 32h |  |
| 33 | 4.2.5 | Horn |  | 4d | 2009-04-06 | 2009-04-10 | 32 |  |  | 93.7d |  | Chandra | 32h |  |
| 34 | 5 | **caGRID Integration** |  | 15d | 2009-03-25 A | 2009-04-14 |  | 67% | 5d | 91d |  |  | 200h | 160h |
| 35 | 5.1 | Alpha Introduce Connector |  | 10d | 2009-03-25 A | 2009-04-07 A |  | 100% |  |  |  | Rakesh D; Shannon | 160h | 160h |
| 36 | 5.2 | Create Views for Mapped Data By Hand (before Data Delivery Pipeline) |  | 2d | 2009-04-08 | 2009-04-09 | 35 |  |  | 91d | 0d | Chandra | 16h |  |
| 37 | 5.3 | Publish First Data Set with Introduce |  | 3d | 2009-04-10 | 2009-04-14 | 36 |  |  | 91d |  | Rakesh D. | 24h |  |
| 38 | 6 | **Mapping Workbench** |  | 19.5d? | 2009-03-25 A | 2009-04-21 |  | 5% | 18.5d? | 86.5d |  |  | 272h | 28.8h |
| 39 | 6.1 | **Phase 1: GUI Only** |  | 18d? | 2009-03-25 A | 2009-04-17 |  | 5% | 17.02d? | 88d |  |  | 248h | 28.8h |
| 40 | 6.1.1 | Finalize GUI Design |  | 3d | 2009-03-25 A | 2009-03-27 |  | 40% | 1.8d | 86.5d | 0d | John D.; John G.; Rob W. | 72h | 28.8h |
| 41 | 6.1.2 | Use Case Development - Avendia again? |  | 3d | 2009-03-25 | 2009-03-27 |  |  |  | 103d |  | Davera; Ketty | 48h |  |
| 42 | 6.1.3 | Create Servlet or Prompt Plugin |  | 10d | 2009-03-30 | 2009-04-10 | 40 |  |  | 86.5d | 0d | John D. | 80h |  |
| 43 | 6.1.4 | Output OntoMapper XML Files |  | 3d | 2009-04-13 | 2009-04-15 | 42 |  |  | 86.5d | 0d | John D. | 24h |  |
| 44 | 6.1.5 | Regression Testing |  | 1d? | 2009-04-16 | 2009-04-16 | 43 |  |  | 86.5d | 0d | Hillari | 8h |  |
| 45 | 6.1.6 | Publish Paper |  | 1d? | 2009-04-17 | 2009-04-17 | 44 |  |  | 88d |  | Group | 8h |  |
| 46 | 6.1.7 | Post Code on RecomData Site for Download |  | 1d? | 2009-04-17 | 2009-04-17 | 44 |  |  | 86.5d | 0d | RecomData | 8h |  |
| 47 | 6.1.8 | Phase 1 Complete | milestone | 0d | 2009-04-17 | 2009-04-17 | 46 |  |  | 86.5d | 0d |  |  |  |
| 48 | 6.2 | **Phase 2: Machine Learning** |  | 1.5d? | 2009-04-20 | 2009-04-21 |  |  |  | 86.5d |  |  | 24h |  |
| 49 | 6.2.1 | Design Phase |  | 0.5d? | 2009-04-20 | 2009-04-20 | 47 |  |  | 86.5d | 0d | John D.; John G. | 8h |  |
| 50 | 6.2.2 | Implementation Phase |  | 1d? | 2009-04-20 | 2009-04-21 | 49 |  |  | 86.5d |  | John D.; John G. | 16h |  |

| ID | WBS | Task | Duration | Start | Finish | Predecessors | Total slack | Resources | Work |
| --- | --- | --- | --- | --- | --- | --- | --- | --- | --- |
| 51 | 7 | **Implementation Projects** | 90d? | 2009-04-16 | 2009-08-19 |  | 0d |  | 1528h |
| 52 | 7.1 | **GRID Projects** | 50d? | 2009-04-16 | 2009-06-24 | 17 | 0d |  | 888h |
| 53 | 7.1.1 | CICTR | 30d | 2009-04-16 | 2009-05-27 |  | 0d | Nick Anderson Team | 240h |
| 54 | 7.1.2 | HSDB | 20d | 2009-04-16 | 2009-05-13 |  | 70d | Ida Sim Team | 160h |
| 55 | 7.1.3 | HOMERUN-QSN | 20d | 2009-05-28 | 2009-06-24 | 53 | 40d | Andy Auerbach Team | 160h |
| 56 | 7.1.4 | DBRD-BioBank Consortium | 20d | 2009-05-28 | 2009-06-24 | 53 | 40d | Jen Puck; Lorraine Frasier Team | 320h |
| 57 | 7.1.5 | COHRI | 1d? | 2009-05-28 | 2009-05-28 | 53 | 59d | Joel White Tieam | 8h |
| 58 | 7.2 | **Ports to Other Platforms** | 60d | 2009-05-28 | 2009-08-19 |  | 0d |  | 640h |
| 59 | 7.2.1 | caAdapter | 60d | 2009-05-28 | 2009-08-19 | 53 | 0d | NCI | 480h |
| 60 | 7.2.2 | Meta Matrix | 20d | 2009-05-28 | 2009-06-24 | 53 | 40d | David Eichman | 160h |
| 61 | 8 | **OntoMapper General Release Beta Program** | 1d? | 2009-05-28 | 2009-05-28 |  | 59d | Rob W.; RecomData | 24h |
| 62 | 8.1 | Documentation | 1d? | 2009-05-28 | 2009-05-28 | 53 | 59d |  |  |
| 63 | 8.2 | Download Site | 1d? | 2009-05-28 | 2009-05-28 | 53 | 59d | RecomData | 8h |
